# Új utazási program bevezetése

Schedule from MS Project, 2004-11-11 to 2005-05-31, costs in €.
TUF-Co

## Calendars

- kalendar projekta: Mon-Fri 08:00-12:00, 13:00-17:00; Sat-Sun off. Exceptions (off unless hours are given): 2005-01-03, 2005-01-07, 2005-01-20, 2005-02-15, 2005-04-30 to 2005-05-01 08:00-12:00, 13:00-17:00, 2005-05-07 to 2005-05-08 08:00-12:00, 13:00-17:00.

## Resources

| Resource | Group | Rate |
| --- | --- | --- |
| A projektcsapat tagja | Projektcsapat | 3.12 |
| Elemző | Marketing osztály |  |
| Tanácsos | Marketing osztály |  |
| Üzletköztő | Eladási osztály |  |
| Útvezető | Központi nyilvántartási osztály |  |
| Számvevő | Pénzügyi osztály |  |
| Könyvelő | Pénzügyi osztály |  |

## Schedule

| ID | WBS | Task | Type | Duration | Start | Finish | Predecessors | Baseline start | Baseline finish | Baseline duration | Total slack | Resources | Work | Cost | Baseline cost |
| --- | --- | --- | --- | --- | --- | --- | --- | --- | --- | --- | --- | --- | --- | --- | --- |
| 1 | 1 | **I. szakasz Előkészületek** |  | 17d | 2004-11-11 | 2004-12-03 |  | 2004-11-11 | 2004-12-03 | 17d | 0d |  | 408h | 11,775 | 11,775 |
| 2 | 1.1 | Az előkészületek szakasz kezdete | milestone | 0d | 2004-11-11 | 2004-11-11 |  | 2004-11-11 | 2004-11-11 | 0d | 0d |  |  |  |  |
| 3 | 1.2 | Az indokoltság kiértékelése |  | 8d | 2004-11-11 | 2004-11-22 | 2 | 2004-11-11 | 2004-11-22 | 8d | 0d | A projektcsapat tagja [300%] | 192h | 600 | 600 |
| 4 | 1.3 | **Ötletterv** |  | 3d | 2004-11-23 | 2004-11-25 |  | 2004-11-23 | 2004-11-25 | 3d | 0d |  | 72h | 225 | 225 |
| 5 | 1.3.1 | Az elvárások pontosítása |  | 3d | 2004-11-23 | 2004-11-25 | 3 | 2004-11-23 | 2004-11-25 | 3d | 0d | A projektcsapat tagja [300%] | 72h | 225 | 225 |
| 6 | 1.4 | **Az alapok kidolgozása** |  | 6d | 2004-11-26 | 2004-12-03 |  | 2004-11-26 | 2004-12-03 | 6d | 0d |  | 144h | 450 | 450 |
| 7 | 1.4.1 | A célok meghatározása |  | 2d | 2004-11-26 | 2004-11-29 | 5 | 2004-11-26 | 2004-11-29 | 2d | 0d | A projektcsapat tagja [300%] | 48h | 150 | 150 |
| 8 | 1.4.2 | A kritériumok meghatározása |  | 2d | 2004-11-30 | 2004-12-01 | 7 | 2004-11-30 | 2004-12-01 | 2d | 0d | A projektcsapat tagja [300%] | 48h | 150 | 150 |
| 9 | 1.4.3 | A terjedelem meghatározása |  | 2d | 2004-12-02 | 2004-12-03 | 8 | 2004-12-02 | 2004-12-03 | 2d | 0d | A projektcsapat tagja [300%] | 48h | 150 | 150 |
| 10 | 1.5 | Az előkészületek szakasz vége | milestone | 0d | 2004-12-03 | 2004-12-03 | 9 | 2004-12-03 | 2004-12-03 | 0d | 0d |  |  |  |  |
| 11 | 2 | **II. szakasz Logisztika** |  | 43d | 2004-12-03 | 2005-02-07 |  | 2004-12-03 | 2005-02-07 | 43d | 0d |  | 976h | 5,375 | 5,375 |
| 12 | 2.1 | A logisztika szakasz kezdete | milestone | 0d | 2004-12-03 | 2004-12-03 | 10 | 2004-12-03 | 2004-12-03 | 0d | 0d |  |  |  |  |
| 13 | 2.2 | Kapcsolat felvétele a nagykövetségekkel |  | 1d | 2004-12-06 | 2004-12-06 | 9, 12 | 2004-12-06 | 2004-12-06 | 1d | 0d | A projektcsapat tagja [300%] | 24h | 95 | 95 |
| 14 | 2.3 | **Szállodák felderítése** |  | 18d | 2004-12-07 | 2004-12-30 |  | 2004-12-07 | 2004-12-30 | 18d | 0d |  | 408h | 2,160 | 2,160 |
| 15 | 2.3.1 | Információk gyűjtése a szállodákról |  | 10d | 2004-12-07 | 2004-12-20 | 13 | 2004-12-07 | 2004-12-20 | 10d | 0d | A projektcsapat tagja [300%] | 240h | 825 | 825 |
| 16 | 2.3.2 | A számításba jövő szállodák kiválasztása |  | 8d | 2004-12-21 | 2004-12-30 | 15 | 2004-12-21 | 2004-12-30 | 8d | 0d | A projektcsapat tagja [200%] | 128h | 1,180 | 1,180 |
| 17 | 2.3.3 | Kapcsolatok felvétele a szállodákkal |  | 5d | 2004-12-24 | 2004-12-30 | 16SS+3d | 2004-12-24 | 2004-12-30 | 5d | 0d | A projektcsapat tagja | 40h | 155 | 155 |
| 18 | 2.4 | **Szállítóvállalat felderítése** |  | 6d | 2004-12-31 | 2005-01-11 |  | 2004-12-31 | 2005-01-11 | 6d | 0d |  | 112h | 470 | 470 |
| 19 | 2.4.1 | Információk gyűjtése a szállítókról |  | 3d | 2004-12-31 | 2005-01-05 | 17 | 2004-12-31 | 2005-01-05 | 3d | 0d | A projektcsapat tagja [300%] | 72h | 255 | 255 |
| 20 | 2.4.2 | A szállító kiválasztása |  | 2d | 2005-01-06 | 2005-01-10 | 19 | 2005-01-06 | 2005-01-10 | 2d | 0d | A projektcsapat tagja [200%] | 32h | 170 | 170 |
| 21 | 2.4.3 | Kapcsolat felvétele a szállítóval |  | 1d | 2005-01-11 | 2005-01-11 | 20SS+2d | 2005-01-11 | 2005-01-11 | 1d | 0d | A projektcsapat tagja | 8h | 45 | 45 |
| 22 | 2.5 | Vízumok beszerzése |  | 6d | 2005-01-12 | 2005-01-19 | 21 | 2005-01-12 | 2005-01-19 | 6d | 0d | A projektcsapat tagja [300%] | 144h | 1,450 | 1,450 |
| 23 | 2.6 | **Szállodák biztosítása** |  | 8d | 2005-01-21 | 2005-02-01 |  | 2005-01-21 | 2005-02-01 | 8d | 0d |  | 192h | 750 | 750 |
| 24 | 2.6.1 | Helyfoglalás |  | 6d | 2005-01-21 | 2005-01-28 | 22 | 2005-01-21 | 2005-01-28 | 6d | 0d | A projektcsapat tagja [300%] | 144h | 525 | 525 |
| 25 | 2.6.2 | Szerződéskötés |  | 2d | 2005-01-31 | 2005-02-01 | 24 | 2005-01-31 | 2005-02-01 | 2d | 0d | A projektcsapat tagja [300%] | 48h | 225 | 225 |

| ID | WBS | Task | Type | Duration | Start | Finish | Predecessors | Baseline start | Baseline finish | Baseline duration | Total slack | Free slack | Resources | Work | Cost | Baseline cost |
| --- | --- | --- | --- | --- | --- | --- | --- | --- | --- | --- | --- | --- | --- | --- | --- | --- |
| 26 | 2.7 | **Szállító biztosítása** |  | 4d | 2005-02-02 | 2005-02-07 |  | 2005-02-02 | 2005-02-07 | 4d | 0d |  |  | 96h | 450 | 450 |
| 27 | 2.7.1 | Rezerválás |  | 3d | 2005-02-02 | 2005-02-04 | 25 | 2005-02-02 | 2005-02-04 | 3d | 0d |  | A projektcsapat tagja [300%] | 72h | 300 | 300 |
| 28 | 2.7.2 | Szerződéskötés |  | 1d | 2005-02-07 | 2005-02-07 | 27 | 2005-02-07 | 2005-02-07 | 1d | 0d |  | A projektcsapat tagja [300%] | 24h | 150 | 150 |
| 29 | 2.8 | A Logisztika szakasz vége | milestone | 0d | 2005-02-07 | 2005-02-07 | 28 | 2005-02-07 | 2005-02-07 | 0d | 0d |  |  |  |  |  |
| 30 | 3 | **III. szakasz Programkészítés** |  | 15d | 2005-02-07 | 2005-03-01 |  | 2005-02-07 | 2005-03-01 | 15d | 0d |  |  | 304h | 950 | 950 |
| 31 | 3.1 | A Programkészítés szakasz kezdete | milestone | 0d | 2005-02-07 | 2005-02-07 | 29 | 2005-02-07 | 2005-02-07 | 0d | 0d |  |  |  |  |  |
| 32 | 3.2 | Az utazás időpontjának kijelölése |  | 6d | 2005-02-08 | 2005-02-16 | 28, 31 | 2005-02-08 | 2005-02-16 | 6d | 0d |  | A projektcsapat tagja | 48h | 150 | 150 |
| 33 | 3.3 | Az útvezető kinevezése |  | 9d | 2005-02-09 | 2005-02-22 | 32SS+1d | 2005-02-09 | 2005-02-22 | 9d | 0d |  | A projektcsapat tagja | 72h | 225 | 225 |
| 34 | 3.4 | Szabad programok meghatározása |  | 8d | 2005-02-10 | 2005-02-22 | 32SS+2d, 33FF | 2005-02-10 | 2005-02-22 | 8d | 0d |  | A projektcsapat tagja | 64h | 200 | 200 |
| 35 | 3.5 | Személyzet biztosítása |  | 5d | 2005-02-23 | 2005-03-01 | 34 | 2005-02-23 | 2005-03-01 | 5d | 0d |  | A projektcsapat tagja [300%] | 120h | 375 | 375 |
| 36 | 3.6 | A Programkészítés szakasz vége | milestone | 0d | 2005-03-01 | 2005-03-01 | 35 | 2005-03-01 | 2005-03-01 | 0d | 7d | 0d |  |  |  |  |
| 37 | 4 | **IV. szakasz Végrehajtás** |  | 69d | 2005-03-01 | 2005-05-31 |  | 2005-03-01 | 2005-05-31 | 69d | 0d |  |  | 1688h | 1,950 | 1,950 |
| 38 | 4.1 | A végrehajtás szakasz kezdete | milestone | 0d | 2005-03-01 | 2005-03-01 | 36 | 2005-03-01 | 2005-03-01 | 0d | 7d |  |  |  |  |  |
| 39 | 4.2 | **Az új utazási program piacra dobása** |  | 62d | 2005-03-11 | 2005-05-31 |  | 2005-03-11 | 2005-05-31 | 62d | 0d |  |  | 1688h | 1,950 | 1,950 |
| 40 | 4.2.1 | **A marketing stratégia kialakítása** |  | 26d | 2005-03-11 | 2005-04-15 |  | 2005-03-11 | 2005-04-15 | 26d | 0d |  |  | 976h | 1,025 | 1,025 |
| 41 | 4.2.1.1 | Reklámanyag készítése |  | 5d | 2005-03-11 | 2005-03-17 | 35FS+7d, 38 | 2005-03-11 | 2005-03-17 | 5d | 0d |  | Elemző; Tanácsos; A projektcsapat tagja | 120h | 125 | 125 |
| 42 | 4.2.1.2 | A marketing stratégia kivitelezése |  | 20d | 2005-03-18 | 2005-04-14 | 41 | 2005-03-18 | 2005-04-14 | 20d | 0d |  | Tanácsos; Elemző; A projektcsapat tagja | 480h | 500 | 500 |
| 43 | 4.2.1.3 | Bemutató tevékenységek |  | 15d | 2005-03-25 | 2005-04-14 | 42FF | 2005-03-25 | 2005-04-14 | 15d | 0d |  | Elemző; Tanácsos; A projektcsapat tagja | 360h | 375 | 375 |
| 44 | 4.2.1.4 | Az érdekeltek kikérdezése |  | 1d | 2005-04-15 | 2005-04-15 | 43 | 2005-04-15 | 2005-04-15 | 1d | 0d |  | Elemző; A projektcsapat tagja | 16h | 25 | 25 |
| 45 | 4.2.2 | **Az új utazási program kivitelezése** |  | 25d | 2005-04-18 | 2005-05-16 |  | 2005-04-18 | 2005-05-16 | 25d | 0d |  |  | 568h | 475 | 475 |
| 46 | 4.2.2.1 | Az utasok nyilvántartásba vétele |  | 1d | 2005-04-18 | 2005-04-18 | 44 | 2005-04-18 | 2005-04-18 | 1d | 0d |  | Üzletköztő; A projektcsapat tagja | 16h | 25 | 25 |
| 47 | 4.2.2.2 | Az indulás megszervezése |  | 5d | 2005-04-19 | 2005-04-25 | 46 | 2005-04-19 | 2005-04-25 | 5d | 0d |  | A projektcsapat tagja [300%] | 120h | 375 | 375 |
| 48 | 4.2.2.3 | A jóváhagyott terv végrehajtása |  | 15d | 2005-04-26 | 2005-05-10 | 47 | 2005-04-26 | 2005-05-10 | 15d | 0d |  | Útvezető [300%] | 360h |  |  |
| 49 | 4.2.2.4 | A visszautazással kapcsolatos kötelezettségek rendezése |  | 3d | 2005-05-12 | 2005-05-16 | 48FS+1d | 2005-05-12 | 2005-05-16 | 3d | 0d |  | Könyvelő; Számvevő; A projektcsapat tagja | 72h | 75 | 75 |

| ID | WBS | Task | Type | Duration | Start | Finish | Predecessors | Baseline start | Baseline finish | Baseline duration | Total slack | Resources | Work | Cost | Baseline cost |
| --- | --- | --- | --- | --- | --- | --- | --- | --- | --- | --- | --- | --- | --- | --- | --- |
| 50 | 4.2.3 | **Operatív jelentések készítése** |  | 6d | 2005-05-24 | 2005-05-31 |  | 2005-05-24 | 2005-05-31 | 6d | 0d |  | 144h | 450 | 450 |
| 51 | 4.2.3.1 | Az eredemények együttes megjelenítése |  | 5d | 2005-05-24 | 2005-05-30 | 49FS+5d | 2005-05-24 | 2005-05-30 | 5d | 0d | A projektcsapat tagja [300%] | 120h | 375 | 375 |
| 52 | 4.2.3.2 | A dokumentáció átadása |  | 1d | 2005-05-31 | 2005-05-31 | 51 | 2005-05-31 | 2005-05-31 | 1d | 0d | A projektcsapat tagja [300%] | 24h | 75 | 75 |
| 53 | 4.3 | A Véhgrehajtás szakasz befejezése | milestone | 0d | 2005-05-31 | 2005-05-31 | 52 | 2005-05-31 | 2005-05-31 | 0d | 0d |  |  |  |  |
